# Target Hall shut down activities

Schedule from MS Project, 2015-02-23 to 2015-04-07, A marks actual dates.

## Calendars

- Standard: Mon-Fri 08:00-12:00, 13:00-17:00; Sat-Sun off. Exceptions (off unless hours are given): 2015-04-03 (Good Friday), 2015-04-06 (Easter Monday).

## Resources

| Resource |
| --- |
| D.Wang |
| D.McDonald |
| T.Cave |
| C.Fisher |
| RPG |
| Westcoast Coring |
| A.Mjos |
| B.Parley |
| D.Jackson |
| G.Minor |
| K.NG |

## Schedule

| ID | WBS | Task | Duration | Start | Finish | Predecessors | Complete | Constraint | Resources | Work | Actual work |
| --- | --- | --- | --- | --- | --- | --- | --- | --- | --- | --- | --- |
| 1 | 1 | **Pre- Module Move** | 9d | 2015-02-23 08:00 A | 2015-03-05 17:00 A |  | 100% |  |  | 88h | 88h |
| 2 | 1.1 | Pedal Wheels and Coils Replacement- ITE | 1d | 2015-02-23 08:00 A | 2015-02-23 17:00 A |  | 100% | start no earlier than 2015-02-23 08:00 | D.Wang; D.McDonald | 8h | 8h |
| 3 | 1.2 | Storage of 6 old Turbo Pumps to Cyclotron Vault | 1d | 2015-02-24 08:00 A | 2015-02-24 17:00 A |  | 100% | start no earlier than 2015-02-24 08:00 | D.Wang; D.McDonald; RPG | 8h | 8h |
| 4 | 1.3 | Pedal wheels and Coils Replacement-ITW | 1d | 2015-02-25 08:00 A | 2015-02-25 17:00 A |  | 100% | start no earlier than 2015-02-25 08:00 | D.McDonald; D.Wang | 8h | 8h |
| 5 | 1.4 | Primary and Secondary Vacuum Vessel Leak Check-ITE | 3d | 2015-03-02 08:00 A | 2015-03-04 17:00 A |  | 100% | finish no earlier than 2015-03-04 17:00 | D.McDonald; D.Wang | 48h | 48h |
| 6 | 1.5 | 5 Shielding Block Move-Storage Area to ITE | 1d | 2015-03-05 08:00 A | 2015-03-05 17:00 A |  | 100% | start no earlier than 2015-03-05 08:00 | D.Wang; D.McDonald | 16h | 16h |
| 7 | 2 | **TM1 Move/Spent Target** | 5d | 2015-03-09 08:00 A | 2015-03-13 17:00 A | 6 | 100% |  |  | 50h | 50h |
| 8 | 2.1 | Cameras Set up-ITW | 0.25d | 2015-03-09 08:00 A | 2015-03-09 10:00 A |  | 100% | start no earlier than 2015-03-09 08:00 | T.Cave | 2h | 2h |
| 9 | 2.2 | Module Move-TM1-ITW to SHC | 0.25d | 2015-03-09 10:00 A | 2015-03-09 12:00 A | 8 | 100% | start no earlier than 2015-03-09 08:00 | D.Wang; T.Cave; D.McDonald; RPG | 8h | 8h |
| 10 | 2.3 | Target Removal/Electrical Check-TM1-ThO-SHC | 0.5d | 2015-03-09 13:00 A | 2015-03-09 17:00 A |  | 100% | start no earlier than 2015-03-09 08:00 | C.Fisher; T.Cave | 8h | 8h |
| 11 | 2.4 | Module Move-TM1-SHC to Silo | 0.5d | 2015-03-10 08:00 A | 2015-03-10 12:00 A |  | 100% | start no earlier than 2015-03-10 08:00 | D.Wang; T.Cave | 8h | 8h |
| 12 | 2.5 | RPG Test on TM1 ThO Target | 1.5d | 2015-03-10 13:00 A | 2015-03-11 17:00 A | 11 | 100% |  | RPG | 12h | 12h |
| 13 | 2.6 | ThO Target Autopsy/Shielding Blocks Move-ITE to ITW/Cameras Set up -ITE | 1d | 2015-03-12 08:00 A | 2015-03-12 17:00 A | 12 | 100% |  |  |  |  |
| 14 | 2.7 | Spent Target Move-ThO-SHC to Vault/Argon Vent ITE | 0.5d | 2015-03-13 08:00 A | 2015-03-13 12:00 A | 13 | 100% |  | C.Fisher; T.Cave; D.Wang | 12h | 12h |
| 15 | 2.8 | Module Move-TM2-CS to Silo | 0.5d | 2015-03-13 13:00 A | 2015-03-13 17:00 A | 14 | 100% |  |  |  |  |
| 16 | 3 | **TM4 Move/Spent Target** | 3d | 2015-03-16 08:00 A | 2015-03-18 17:00 A | 15 | 100% |  |  | 48h | 48h |
| 17 | 3.1 | Module Move-TM4-ITE to SHC | 0.5d | 2015-03-16 08:00 A | 2015-03-16 12:00 A |  | 100% |  | D.Wang; T.Cave; D.McDonald | 12h | 12h |
| 18 | 3.2 | Target Removal/Electrical Check-TM4-UCx-SHC | 0.5d | 2015-03-16 13:00 A | 2015-03-16 17:00 A | 17 | 100% |  | C.Fisher; T.Cave | 8h | 8h |
| 19 | 3.3 | Module Move-TM4 -SHC to CS | 1d | 2015-03-17 08:00 A | 2015-03-17 17:00 A | 18 | 100% | start no earlier than 2015-03-13 08:00 | T.Cave; D.Wang | 16h | 16h |
| 20 | 3.4 | Spent Target Move-UCx-SHC to Vault | 0.5d | 2015-03-18 08:00 A | 2015-03-18 12:00 A | 19 | 100% |  | C.Fisher; T.Cave; D.Wang | 12h | 12h |
| 21 | 3.5 | Preparation-New Holes Coring | 0.5d | 2015-03-18 13:00 A | 2015-03-18 17:00 A | 20 | 100% | start no earlier than 2015-03-17 08:00 |  |  |  |
| 22 | 4 | **Handrail Holes Coring** | 3d | 2015-03-19 08:00 A | 2015-03-23 17:00 A | 21 | 100% |  |  | 48h | 48h |
| 23 | 4.1 | New Holes Coring-Westcoast coring/ Shielding Blocks to ITE | 2d | 2015-03-19 08:00 A | 2015-03-20 17:00 A |  | 100% |  | D.Wang; Westcoast Coring | 32h | 32h |
| 24 | 4.2 | Clean up and Restore | 1d | 2015-03-23 08:00 A | 2015-03-23 17:00 A | 23 | 100% | start no earlier than 2015-03-23 08:00 | D.Wang; RPG | 16h | 16h |

| ID | WBS | Task | Duration | Start | Finish | Predecessors | Complete | Remaining | Total slack | Constraint | Resources | Work | Actual work |
| --- | --- | --- | --- | --- | --- | --- | --- | --- | --- | --- | --- | --- | --- |
| 25 | 5 | **First HP Ta Surface Target on TM4 Ready for ITE/TM2 Refurbish Restart** | 9d | 2015-03-24 08:00 A | 2015-04-07 17:00 | 24, 23 | 44% | 5d | 0d |  |  | 128h | 50h |
| 26 | 5.1 | HP Ta Surface Target Insert into SHC | 0.25d | 2015-03-24 08:00 A | 2015-03-24 10:00 A |  | 100% |  |  | start no earlier than 2015-03-24 08:00 | C.Fisher | 2h | 2h |
| 27 | 5.2 | Module Move-TM4-CS to SHC | 0.75d | 2015-03-24 10:00 A | 2015-03-24 17:00 A | 26 | 100% |  |  |  | T.Cave; D.Wang | 12h | 12h |
| 28 | 5.3 | Target Installation-TM4-HP Ta/Leak Check/Electrical Check | 0.5d | 2015-03-25 08:00 A | 2015-03-25 12:00 A | 27 | 100% |  |  |  | C.Fisher; T.Cave; D.Wang | 12h | 12h |
| 29 | 5.4 | Module Move-TM4-SHC to CS | 0.5d | 2015-03-25 13:00 A | 2015-03-25 17:00 A | 28 | 100% |  |  |  | T.Cave; D.Wang | 8h | 8h |
| 30 | 5.5 | Connect and Pump down/Helium pressure test -TM4 at CS | 2d | 2015-03-26 08:00 A | 2015-03-27 17:00 A | 29 | 100% |  |  |  | D.Wang | 16h | 16h |
| 31 | 5.6 | TM4 Fully Conditioning at CS with HV and Heaters on. | 2d | 2015-03-30 08:00 | 2015-03-31 17:00 | 30 |  |  | 0d |  | A.Mjos; B.Parley | 32h |  |
| 32 | 5.7 | Cameras Set up-ITE/TM4 and CS Venting | 0.25d | 2015-04-01 08:00 | 2015-04-01 10:00 | 31 |  |  | 0d |  | T.Cave | 2h |  |
| 33 | 5.8 | Module Move-TM4-CS to ITE | 0.75d | 2015-04-01 10:00 | 2015-04-01 17:00 | 32 |  |  | 0d |  | T.Cave; D.Wang | 12h |  |
| 34 | 5.9 | Module Move-TM2 -Silo to SHC | 0.5d | 2015-04-02 08:00 | 2015-04-02 12:00 | 33 |  |  | 0d | start no earlier than 2015-04-02 08:00 | D.Wang; T.Cave | 8h |  |
| 35 | 5.10 | Connect and Pump down -TM4 at ITE | 0.5d | 2015-04-02 13:00 | 2015-04-02 17:00 | 34 |  |  | 0d | start no earlier than 2015-04-02 08:00 | D.Wang; D.McDonald | 8h |  |
| 36 | 5.11 | 5 Shielding Blocks Move-Storage Area to ITE/ ITE Ready | 1d | 2015-04-07 08:00 | 2015-04-07 17:00 | 35 |  |  | 0d |  | D.Wang; D.McDonald | 16h |  |
